# crnograma enviado 20-03-07

Schedule from MS Project, 2007-11-03 to 2007-12-22.
Grupo Romero

## Calendars

- Estándar: Mon-Sun 08:00-12:00, 13:00-17:00. Exceptions (off unless hours are given): 2007-11-01 to 2008-02-29 08:00-12:00, 13:00-17:00.

## Schedule

| ID | WBS | Task | Duration | Start | Finish | Predecessors | Total slack | Free slack | Constraint | Deadline |
| --- | --- | --- | --- | --- | --- | --- | --- | --- | --- | --- |
| 1 | 1 | **MALVINAS** | 50d | 2007-11-03 | 2007-12-22 |  | 0d |  |  |  |
| 2 | 1.1 | **inicio** | 50d | 2007-11-03 | 2007-12-22 |  | 0d |  |  |  |
| 3 | 1.1.1 | **01 MÓDULO DORMITORIO 32P PERSONAS MALVINAS** | 50d | 2007-11-03 | 2007-12-22 |  | 0d |  |  | 2008-11-03 |
| 4 | 1.1.1.1 | **INICIO DE TRABAJOS EN TERRENO-LOTE 88** | 50d | 2007-11-03 | 2007-12-22 |  | 0d |  |  |  |
| 5 | 1.1.1.1.1 | **LOSA DE CONCRETO** | 14d | 2007-11-03 | 2007-11-16 |  | 0d |  |  |  |
| 6 | 1.1.1.1.1.1 | ENCOFRADO Y DENSENCOFRADO NORMAL LOSA | 4d | 2007-11-03 | 2007-11-06 |  | 0d |  |  |  |
| 7 | 1.1.1.1.1.2 | CONCRETO f`c210kg/cm2 LOSA CIMENTACION | 4d | 2007-11-10 | 2007-11-13 | 8 | 0d |  | start no earlier than 2007-08-05 |  |
| 8 | 1.1.1.1.1.3 | ACERO Fy= 4200 kg/CM2 LOSA SIN CONCRETO | 5d | 2007-11-05 | 2007-11-09 | 6FS-2d | 0d |  | start no earlier than 2007-08-02 |  |
| 9 | 1.1.1.1.1.4 | CURADO QUIMICO CONCRETO | 3d | 2007-11-14 | 2007-11-16 | 7 | 0d |  | start no earlier than 2007-08-05 |  |
| 10 | 1.1.1.1.2 | **MONTAJE RBS** | 28d | 2007-11-17 | 2007-12-14 |  | 0d |  |  |  |
| 11 | 1.1.1.1.2.1 | TRABAJO PRELIMINARES | 1d | 2007-11-17 | 2007-11-17 | 9 | 0d |  | start no earlier than 2007-11-17 |  |
| 12 | 1.1.1.1.2.2 | **ESTRUCTURAS METALICAS Y COBERTURAS** | 16d | 2007-11-20 | 2007-12-05 |  | 0d |  |  |  |
| 13 | 1.1.1.1.2.2.1 | **REFUERZO DE MURO RBS** | 10d | 2007-11-20 | 2007-11-29 |  | 0d |  |  |  |
| 14 | 1.1.1.1.2.2.1.1 | COLUMNA TC 50X50X1.2mm, 2<H<=3.0 | 5d | 2007-11-20 | 2007-11-24 | 27 | 0d |  | start no earlier than 2007-03-29 |  |
| 15 | 1.1.1.1.2.2.1.2 | COLUMNA TC 50X50X1.5mm, 2<H<=3.0 | 5d | 2007-11-25 | 2007-11-29 | 14 | 23d |  | start no earlier than 2007-11-20 |  |
| 16 | 1.1.1.1.2.2.2 | **REFUERZO DE TECHO RBS** | 12d | 2007-11-24 | 2007-12-05 |  | 17d |  |  |  |
| 17 | 1.1.1.1.2.2.2.1 | VIGA TR 50X100X2.0mm , 1.0<L<=2.0 | 4d | 2007-11-24 | 2007-11-27 | 24SS+4d | 20d | 0d | start no earlier than 2007-11-23 |  |
| 18 | 1.1.1.1.2.2.2.2 | VIGA TR 50X150X2.5mm, 2.5<L<=4.0 | 5d | 2007-11-28 | 2007-12-02 | 17 | 20d |  | start no earlier than 2007-11-25 |  |
| 19 | 1.1.1.1.2.2.2.3 | PLATINA 2X3/16" | 3d | 2007-12-03 | 2007-12-05 | 24SS+13d | 58d |  |  |  |
| 20 | 1.1.1.1.2.2.2.4 | SOPORTE DE ALERO | 1d | 2007-12-04 | 2007-12-04 |  | 18d |  | start no earlier than 2007-12-04 |  |
| 21 | 1.1.1.1.2.2.2.5 | VIGA TC 50X50X1.5mm,0.1<L<=1.0 | 2d | 2007-12-02 | 2007-12-03 | 24SS+12d | 60d |  |  |  |
| 22 | 1.1.1.1.2.2.2.6 | VIGA TC 50X50X1.5mm,1.0<L<=1.5 | 2d | 2007-12-04 | 2007-12-05 | 24SS+14d | 58d |  |  |  |
| 23 | 1.1.1.1.2.3 | **SISTEMA RBS** | 27d | 2007-11-18 | 2007-12-14 |  | 0d |  |  |  |
| 24 | 1.1.1.1.2.3.1 | MUROS RBS 64 | 17d | 2007-11-20 | 2007-12-06 | 14SS | 0d |  | start no earlier than 2007-05-15 |  |
| 25 | 1.1.1.1.2.3.2 | MARCO PUERTA RBS64 | 2d | 2007-12-08 | 2007-12-09 | 24 | 49d | 0d | start no earlier than 2007-12-08 |  |
| 26 | 1.1.1.1.2.3.3 | CONTRAMARCO VENTANA BS64 | 1d | 2007-12-07 | 2007-12-07 | 24 | 55d | 0d | start no earlier than 2007-05-11 |  |
| 27 | 1.1.1.1.2.3.4 | MARCO RBS64 PARA CIMBRAR MUROS | 2d | 2007-11-18 | 2007-11-19 | 11 | 0d |  |  |  |
| 28 | 1.1.1.1.2.3.5 | TECHO RBS64 | 16d | 2007-11-25 | 2007-12-10 | 24SS+5d | 0d |  | start no earlier than 2007-07-26 |  |
| 29 | 1.1.1.1.2.3.6 | TAPA DE ALERO Y TIMPANO RBS64 | 1d | 2007-11-29 | 2007-11-29 | 28SS+4d | 64d |  |  |  |
| 30 | 1.1.1.1.2.3.7 | TAPA DE PENDIENTE RBS64 | 1d | 2007-12-07 | 2007-12-07 | 24 | 56d |  |  |  |
| 31 | 1.1.1.1.2.3.8 | CUMBRERA | 1d | 2007-12-10 | 2007-12-10 | 28FS-1d | 53d |  |  |  |
| 32 | 1.1.1.1.2.3.9 | TEJA RBS64 | 6d | 2007-12-08 | 2007-12-13 | 28FS-3d | 49d | 0d |  |  |
| 33 | 1.1.1.1.2.3.10 | KIT DE REPARACION RBS | 1d | 2007-12-14 | 2007-12-14 | 32 | 49d |  |  |  |

| ID | WBS | Task | Duration | Start | Finish | Predecessors | Total slack | Free slack | Constraint |
| --- | --- | --- | --- | --- | --- | --- | --- | --- | --- |
| 34 | 1.1.1.1.2.4 | **ELEMENTOS COMPLEMENTARIOS SISTEMA RBS** | 14d | 2007-12-01 | 2007-12-14 |  | 8d |  |  |
| 35 | 1.1.1.1.2.4.1 | SELLO HERMETICO MARCO BASICO | 2d | 2007-12-01 | 2007-12-02 | 24FS-9d | 61d |  | start no earlier than 2007-12-01 |
| 36 | 1.1.1.1.2.4.2 | SELLO HERMETICO EN EXTERIORES | 3d | 2007-12-12 | 2007-12-14 | 32FS-2d | 49d |  |  |
| 37 | 1.1.1.1.2.4.3 | SELLO HERMETICO EN INTERIORES | 3d | 2007-12-12 | 2007-12-14 | 32FS-2d | 49d |  | start no earlier than 2007-08-06 |
| 38 | 1.1.1.1.3 | **INSTALACIONES SANITARIAS** | 43d | 2007-11-07 | 2007-12-19 |  | 3d |  |  |
| 39 | 1.1.1.1.3.1 | **SISTEMA DE DESAGUE** | 32d | 2007-11-07 | 2007-12-08 |  | 14d |  |  |
| 40 | 1.1.1.1.3.1.1 | **SALIDAS** | 2d | 2007-11-07 | 2007-11-08 |  | 32d |  |  |
| 41 | 1.1.1.1.3.1.1.1 | SALIDA DE DESAGUE PVC-SAL 2" | 2d | 2007-11-07 | 2007-11-08 | 6 | 85d |  | start no earlier than 2007-08-06 |
| 42 | 1.1.1.1.3.1.1.2 | SALIDA DE DESAGUE PVC -SAL 4" | 1d | 2007-11-08 | 2007-11-08 | 6 | 44d | 0d | start no earlier than 2007-11-08 |
| 43 | 1.1.1.1.3.1.1.3 | SALIDA DE VENTILACION PVC 2" | 1d | 2007-11-07 | 2007-11-07 | 6 | 86d |  | start no earlier than 2007-08-06 |
| 44 | 1.1.1.1.3.1.2 | **ADITAMIENTOS VARIOS** | 12d | 2007-11-09 | 2007-11-20 |  | 32d |  |  |
| 45 | 1.1.1.1.3.1.2.1 | SUMIDERO DE BRONCE 2" | 1d | 2007-11-09 | 2007-11-09 | 51SS | 53d |  | start no earlier than 2007-09-12 |
| 46 | 1.1.1.1.3.1.2.2 | REGISTRO DE BRONCE 4" | 1d | 2007-11-09 | 2007-11-09 | 52SS | 53d |  | start no earlier than 2007-09-12 |
| 47 | 1.1.1.1.3.1.2.3 | REGISTRO DE BRONCE 2" | 1d | 2007-11-09 | 2007-11-09 | 51SS | 53d |  | start no earlier than 2007-09-12 |
| 48 | 1.1.1.1.3.1.2.4 | REGISTRO DE BRONCE 4" | 1d | 2007-11-09 | 2007-11-09 | 52SS | 53d |  | start no earlier than 2007-09-12 |
| 49 | 1.1.1.1.3.1.2.5 | SOMBRERO DE VENTILACION PVC 2" | 1d | 2007-11-20 | 2007-11-20 | 24SS | 73d |  | start no earlier than 2007-09-12 |
| 50 | 1.1.1.1.3.1.3 | **REDES DE DISTRIBUCION** | 12d | 2007-11-09 | 2007-11-20 |  | 32d |  |  |
| 51 | 1.1.1.1.3.1.3.1 | TUBERIA PVC SAL P/DESAGUE 2" | 12d | 2007-11-09 | 2007-11-20 | 41 | 42d | 0d | start no earlier than 2007-08-06 |
| 52 | 1.1.1.1.3.1.3.2 | TUBERIA PVC SAL P/DESAGUE 4" | 10d | 2007-11-09 | 2007-11-18 | 42 | 44d | 0d | start no earlier than 2007-08-06 |
| 53 | 1.1.1.1.3.1.4 | **CAMARA DE INSPECCION** | 1d | 2007-12-08 | 2007-12-08 |  | 14d |  |  |
| 54 | 1.1.1.1.3.1.4.1 | CAJA DE REG. ALB. 12"X24" TAPA FO. FDO. | 1d | 2007-12-08 | 2007-12-08 | 26 | 55d |  | start no earlier than 2007-08-31 |
| 55 | 1.1.1.1.3.2 | **SISTEMA DE AGUA FRIA** | 11d | 2007-11-10 | 2007-11-20 |  | 32d |  |  |
| 56 | 1.1.1.1.3.2.1 | **SALIDA** | 2d | 2007-11-10 | 2007-11-11 |  | 32d |  |  |
| 57 | 1.1.1.1.3.2.1.1 | SALIDA DE AGUA FRIA PVC - SAP 1/2" | 2d | 2007-11-10 | 2007-11-11 | 7SS | 81d | 0d | start no earlier than 2007-08-06 |

| ID | WBS | Task | Duration | Start | Finish | Predecessors | Total slack | Free slack | Constraint |
| --- | --- | --- | --- | --- | --- | --- | --- | --- | --- |
| 58 | 1.1.1.1.3.2.2 | **REDES DE DISTRIBUCION** | 9d | 2007-11-12 | 2007-11-20 |  | 32d |  |  |
| 59 | 1.1.1.1.3.2.2.1 | TUBERIA PVC -SAP P/AGUA FRIA 1/2" | 5d | 2007-11-12 | 2007-11-16 | 57 | 42d | 0d | start no earlier than 2007-08-06 |
| 60 | 1.1.1.1.3.2.2.2 | TUBERIA PVC -SAP P/AGUA FRIA 1" | 4d | 2007-11-17 | 2007-11-20 | 59 | 42d | 0d | start no earlier than 2007-08-06 |
| 61 | 1.1.1.1.3.2.3 | **LLAVES , VALVULAS** | 1d | 2007-11-17 | 2007-11-17 |  | 35d |  |  |
| 62 | 1.1.1.1.3.2.3.1 | VALVULA COMPUERTA PESADA 1/2" | 1d | 2007-11-17 | 2007-11-17 | 59 | 45d |  | start no earlier than 2007-08-12 |
| 63 | 1.1.1.1.3.2.4 | **PIEZAS VARIAS** | 1d | 2007-11-17 | 2007-11-17 |  | 35d |  |  |
| 64 | 1.1.1.1.3.2.4.1 | CAJA DE REG. ALB. 12"X20" TAPA FO. FDO. | 1d | 2007-11-17 | 2007-11-17 | 60SS | 45d |  | start no earlier than 2007-08-31 |
| 65 | 1.1.1.1.3.3 | **SISTEMA DE AGUA CALIENTE** | 6d | 2007-11-10 | 2007-11-15 |  | 37d |  |  |
| 66 | 1.1.1.1.3.3.1 | **SALIDAS** | 1d | 2007-11-10 | 2007-11-10 |  | 38d |  |  |
| 67 | 1.1.1.1.3.3.1.1 | SALIDA CPVC P/AGUA CALIENTE 1/2" | 1d | 2007-11-10 | 2007-11-10 | 57SS | 83d |  | start no earlier than 2007-08-06 |
| 68 | 1.1.1.1.3.3.2 | **REDES DE DISTRIBUCION** | 4d | 2007-11-11 | 2007-11-14 |  | 38d |  |  |
| 69 | 1.1.1.1.3.3.2.1 | TUBERIA CPVC P/AGUA CALIENTE 1/2" | 4d | 2007-11-11 | 2007-11-14 | 67 | 48d |  | start no earlier than 2007-08-06 |
| 70 | 1.1.1.1.3.3.2.2 | TUBERIA CPVC P/AGUA CALIENTE 3/4" | 3d | 2007-11-11 | 2007-11-13 | 67 | 49d |  |  |
| 71 | 1.1.1.1.3.3.3 | **LLAVES VALVULAS** | 1d | 2007-11-15 | 2007-11-15 |  | 37d |  |  |
| 72 | 1.1.1.1.3.3.3.1 | VALVULA COMPUERTA PESADA 1/2" | 1d | 2007-11-15 | 2007-11-15 | 7SS | 47d |  | start no earlier than 2007-11-15 |
| 73 | 1.1.1.1.3.4 | **APARATOS SANITARIOS** | 10d | 2007-12-10 | 2007-12-19 |  | 3d |  |  |
| 74 | 1.1.1.1.3.4.1 | INODORO TREBOL CADET | 2d | 2007-12-10 | 2007-12-11 | 25 | 52d |  | start no earlier than 2007-09-10 |
| 75 | 1.1.1.1.3.4.2 | DISPENSADOR PAPEL HIGIENICO SIMPLE DE SOBREPONER | 1d | 2007-12-11 | 2007-12-11 | 25 | 21d |  | start no earlier than 2007-12-11 |
| 76 | 1.1.1.1.3.4.3 | LAVATORIO TREBOL MANANTIAL | 1d | 2007-12-13 | 2007-12-13 | 25 | 19d |  | start no earlier than 2007-12-13 |
| 77 | 1.1.1.1.3.4.4 | MEZCLADORA VAINSA PARA LAVATORIO | 1d | 2007-12-13 | 2007-12-13 | 25 | 18d | 2d | start no earlier than 2007-12-13 |
| 78 | 1.1.1.1.3.4.5 | ESPEJO | 1d | 2007-12-16 | 2007-12-16 | 25 | 16d |  | start no earlier than 2007-12-16 |
| 79 | 1.1.1.1.3.4.6 | URINARIO TREBOL CADET | 1d | 2007-12-12 | 2007-12-12 | 25 | 20d |  | start no earlier than 2007-12-12 |
| 80 | 1.1.1.1.3.4.7 | POZA DE DUCHA DE FIBRA DE VIDRIO | 3d | 2007-12-14 | 2007-12-16 | 25 | 14d | 0d | start no earlier than 2007-12-14 |
| 81 | 1.1.1.1.3.4.8 | MEZCLADORA PARA DUCHA VAINSA (02 LLAVS) | 2d | 2007-12-16 | 2007-12-17 | 80FS-1d | 14d | 0d |  |
| 82 | 1.1.1.1.3.4.9 | CORTINA DE DUCHA INC. BARRA Y GANCHOS | 1d | 2007-12-19 | 2007-12-19 | 81 | 13d |  | start no earlier than 2007-12-19 |
| 83 | 1.1.1.1.3.4.10 | JABONERA | 1d | 2007-12-16 | 2007-12-16 | 77 | 16d |  | start no earlier than 2007-12-16 |
| 84 | 1.1.1.1.3.4.11 | GANCHO DOBLE CROMADO | 1d | 2007-12-18 | 2007-12-18 | 81 | 14d |  | start no earlier than 2007-12-18 |

| ID | WBS | Task | Duration | Start | Finish | Predecessors | Total slack | Free slack | Constraint |
| --- | --- | --- | --- | --- | --- | --- | --- | --- | --- |
| 85 | 1.1.1.1.4 | **INSTALACIONES ELECTRICAS** | 13d | 2007-12-08 | 2007-12-20 |  | 2d |  |  |
| 86 | 1.1.1.1.4.1 | **SALIDAS** | 9d | 2007-12-08 | 2007-12-16 |  | 6d |  |  |
| 87 | 1.1.1.1.4.1.1 | SALIDA DE TECHO PARA LUMINARIA | 6d | 2007-12-08 | 2007-12-13 | 28SS+5d | 17d | 0d | start no earlier than 2007-12-08 |
| 88 | 1.1.1.1.4.1.2 | SALIDA DE PARED PARA LUMINARIA | 1d | 2007-12-11 | 2007-12-11 | 24SS+6d | 5d | 0d | start no earlier than 2007-12-11 |
| 89 | 1.1.1.1.4.1.3 | SALIDA DOBLE INTERRUPTOR UNIPOLAR | 5d | 2007-12-09 | 2007-12-13 | 24SS+8d | 7d | 0d | start no earlier than 2007-12-09 |
| 90 | 1.1.1.1.4.1.4 | SALIDA PARA THERMA | 1d | 2007-12-14 | 2007-12-14 | 89 | 7d | 3d |  |
| 91 | 1.1.1.1.4.1.5 | SALIDA TOMACORRIENTE DOBLE POLARIZADO CON TIERRA | 6d | 2007-12-11 | 2007-12-16 | 24SS | 6d | 0d | start no earlier than 2007-12-11 |
| 92 | 1.1.1.1.4.1.6 | SALIDA DE DATA | 1d | 2007-12-15 | 2007-12-15 | 91SS | 7d |  | start no earlier than 2007-12-15 |
| 93 | 1.1.1.1.4.1.7 | SALIDA DE TV SIN CABLEAR | 1d | 2007-12-15 | 2007-12-15 | 91SS | 7d |  | start no earlier than 2007-12-15 |
| 94 | 1.1.1.1.4.1.8 | SALIDA DE FUERZA PARA EXTRACTORES | 1d | 2007-12-16 | 2007-12-16 | 91SS | 2d | 0d | start no earlier than 2007-12-16 |
| 95 | 1.1.1.1.4.2 | **CONDUCTORES** | 7d | 2007-12-12 | 2007-12-18 |  | 4d |  |  |
| 96 | 1.1.1.1.4.2.1 | CABLE TW N14 AWG | 2d | 2007-12-12 | 2007-12-13 | 87FS-4d, 88 | 5d | 0d |  |
| 97 | 1.1.1.1.4.2.2 | CABLE TW N12 AWG | 2d | 2007-12-16 | 2007-12-17 | 91FS-4d | 5d | 0d | start no earlier than 2007-12-16 |
| 98 | 1.1.1.1.4.2.3 | CABLE N8 AWG | 2d | 2007-12-17 | 2007-12-18 | 94 | 2d | 0d |  |
| 99 | 1.1.1.1.4.3 | **TABLEROS ELECTRICOS** | 2d | 2007-12-19 | 2007-12-20 |  | 2d |  |  |
| 100 | 1.1.1.1.4.3.1 | TABLEROS PARA AIRES ACONDICIONADOS | 1d | 2007-12-19 | 2007-12-19 | 98 | 2d | 0d |  |
| 101 | 1.1.1.1.4.3.2 | TABLERO GENERAL G1 | 1d | 2007-12-20 | 2007-12-20 | 96FS-2d, 97FS-2d, 100 | 2d |  | start no earlier than 2007-12-18 |
| 102 | 1.1.1.1.4.4 | **ARTEFACTOS DE ILUMINACION** | 4d | 2007-12-14 | 2007-12-17 |  | 5d |  |  |
| 103 | 1.1.1.1.4.4.1 | REJILLA DE ALUMINIO T8 2X36W | 4d | 2007-12-14 | 2007-12-17 | 96 | 5d |  | start no earlier than 2007-08-04 |
| 104 | 1.1.1.1.4.4.2 | BRAQUETE NEGRO OVALADO P/EXTERIORES | 1d | 2007-12-14 | 2007-12-14 | 96 | 8d |  | start no earlier than 2007-08-04 |
| 105 | 1.1.1.1.4.4.3 | LUMINARIA DOWNLIGHT P/ADOSAR 2X26W | 1d | 2007-12-14 | 2007-12-14 | 96 | 8d |  | start no earlier than 2007-08-04 |
| 106 | 1.1.1.1.4.5 | **EQUIPOS VARIOS** | 1d | 2007-12-16 | 2007-12-16 |  | 6d |  |  |
| 107 | 1.1.1.1.4.5.1 | THERMAS 125 LT VERTICAL | 1d | 2007-12-16 | 2007-12-16 |  | 6d |  | start no earlier than 2007-12-16 |
| 108 | 1.1.1.1.4.5.2 | EXTRACTORES BAÑOS HASTA 7m3 | 1d | 2007-12-16 | 2007-12-16 | 90 | 6d |  | start no earlier than 2007-12-16 |

| ID | WBS | Task | Type | Duration | Start | Finish | Predecessors | Total slack | Free slack | Constraint |
| --- | --- | --- | --- | --- | --- | --- | --- | --- | --- | --- |
| 109 | 1.1.1.1.5 | **CARPINTERIA** |  | 7d | 2007-12-11 | 2007-12-17 |  | 5d |  |  |
| 110 | 1.1.1.1.5.1 | VENTANA RBS 1061X1000mm |  | 3d | 2007-12-11 | 2007-12-13 | 28 | 50d |  | start no earlier than 2007-09-02 |
| 111 | 1.1.1.1.5.2 | VENTANA RBS 560X300mm |  | 1d | 2007-12-11 | 2007-12-11 | 28 | 45d | 0d | start no earlier than 2007-09-02 |
| 112 | 1.1.1.1.5.3 | PUERTA CONTRAPLACADA (1HOJA ) H= 2100 876 X2100mm |  | 1d | 2007-12-12 | 2007-12-12 | 111 | 46d | 0d |  |
| 113 | 1.1.1.1.5.4 | PUERTA CONTRAPLACADA (1HOJA ) H= 2100 811 X2100mm |  | 5d | 2007-12-12 | 2007-12-16 | 111 | 15d | 0d |  |
| 114 | 1.1.1.1.5.5 | PUERTA CONTRAPLACADA (1HOJA ) H= 1700 718 X1700mm |  | 2d | 2007-12-12 | 2007-12-13 | 111 | 50d |  |  |
| 115 | 1.1.1.1.5.6 | PERSIANAS |  | 1d | 2007-12-17 | 2007-12-17 | 113 | 15d |  |  |
| 116 | 1.1.1.1.6 | **CERRAJERIA** |  | 4d | 2007-12-12 | 2007-12-15 |  | 7d |  |  |
| 117 | 1.1.1.1.6.1 | BISAGRAS CAPUCHINAS DE 4"X4" |  | 4d | 2007-12-12 | 2007-12-15 | 112SS | 7d |  |  |
| 118 | 1.1.1.1.6.2 | CERRADURA CILINDRICA PRINCIPAL |  | 1d | 2007-12-12 | 2007-12-12 | 112SS | 51d |  |  |
| 119 | 1.1.1.1.6.3 | CERRADURA CILINDRICA DORMITORIO |  | 1d | 2007-12-12 | 2007-12-12 | 112SS | 51d |  |  |
| 120 | 1.1.1.1.6.4 | CERROJO PARA CUBICULO INODORO |  | 1d | 2007-12-12 | 2007-12-12 | 112SS | 51d |  |  |
| 121 | 1.1.1.1.7 | **ACABADOS** |  | 18d | 2007-12-05 | 2007-12-22 |  | 0d |  |  |
| 122 | 1.1.1.1.7.1 | PISO CERAMICO 42X42CM COLOR INTERIORES |  | 16d | 2007-12-05 | 2007-12-20 | 28FS-6d | 0d |  | start no earlier than 2007-11-27 |
| 123 | 1.1.1.1.7.2 | SELLADO DE JUNTAS CONTRACCION CERAMICO |  | 2d | 2007-12-21 | 2007-12-22 | 122 | 0d |  | start no earlier than 2007-06-14 |
| 124 | 1.1.2 | FIN | milestone | 0d | 2007-12-22 | 2007-12-22 | 123 | 0d |  |  |
