# cronograma 5.3.5 drywall

Schedule from MS Project, 2008-01-27 to 2008-02-21.
MC

## Calendars

- Estándar: Mon-Sun 08:00-12:00, 13:00-17:00.

## Schedule

| ID | WBS | Task | Type | Duration | Start | Finish | Predecessors | Total slack | Free slack | Constraint |
| --- | --- | --- | --- | --- | --- | --- | --- | --- | --- | --- |
| 1 | 1 | **VIVIENDA ECONOMICA** |  | 24.92d | 2008-01-27 | 2008-02-21 |  | 0d |  |  |
| 2 | 1.1 | Inicio | milestone | 0d | 2008-01-27 | 2008-01-27 |  | 0d |  |  |
| 3 | 1.2 | Obras preliminares |  | 1d | 2008-01-27 | 2008-01-28 | 2SS | 0d |  |  |
| 4 | 1.3 | Movimiento de tierras |  | 2d | 2008-01-28 | 2008-01-30 | 3 | 0d |  |  |
| 5 | 1.4 | Obras de concreto |  | 6d | 2008-01-30 | 2008-02-05 | 4 | 0d |  |  |
| 6 | 1.5 | **SISTEMA DRYWALL** |  | 10.92d | 2008-02-05 | 2008-02-16 |  | 0d |  |  |
| 7 | 1.5.1 | Tabique interior con estructura metalica |  | 1.4d | 2008-02-05 | 2008-02-06 | 5 | 0d |  |  |
| 8 | 1.5.2 | Tabique interior-sanitario con estructura |  | 1.96d | 2008-02-05 | 2008-02-07 | 7SS+0.5d | 0d |  |  |
| 9 | 1.5.3 | Tabique interior-exterior con estructura |  | 3.36d | 2008-02-07 | 2008-02-10 | 8 | 0d |  |  |
| 10 | 1.5.4 | Tabique sanitario-exterior con estructura |  | 1.1d | 2008-02-10 | 2008-02-12 | 9 | 0d |  |  |
| 11 | 1.5.5 | Cielo raso |  | 4d | 2008-02-12 | 2008-02-16 | 10 | 0d |  |  |
| 12 | 1.6 | Ventanas |  | 1d | 2008-02-12 | 2008-02-13 | 10 | 8d |  |  |
| 13 | 1.7 | Puertas |  | 1d | 2008-02-12 | 2008-02-13 | 10 | 6d | 0d |  |
| 14 | 1.8 | Pisos y revestimientos |  | 5d | 2008-02-16 | 2008-02-21 | 11 | 0d |  |  |
| 15 | 1.9 | Pintura en muros y cielo raso |  | 6d | 2008-02-15 | 2008-02-21 | 11SS+3d | 0d |  |  |
| 16 | 1.10 | Aparatos sanitarios |  | 2d | 2008-02-13 | 2008-02-15 | 13 | 6d |  | start no earlier than 2008-02-08 |
| 17 | 1.11 | Instalacion sanitaria |  | 2d | 2008-02-05 | 2008-02-07 | 5SS+2d | 13.92d |  | start no earlier than 2008-02-05 |
| 18 | 1.12 | Instalacion electrica |  | 2d | 2008-02-11 | 2008-02-13 | 11SS-1d | 8d |  | start no earlier than 2008-02-05 |
