# cronograma 5.3.5 rbs

Schedule from MS Project, 2008-01-27 to 2008-02-13.
MC

## Calendars

- Estándar: Mon-Sun 08:00-12:00, 13:00-17:00.

## Schedule

| ID | WBS | Task | Type | Duration | Start | Finish | Predecessors | Total slack | Free slack | Constraint |
| --- | --- | --- | --- | --- | --- | --- | --- | --- | --- | --- |
| 1 | 1 | **VIVIENDA ECONOMICA** |  | 17.74d | 2008-01-27 | 2008-02-13 |  | 0d |  |  |
| 2 | 1.1 | inicio | milestone | 0d | 2008-01-27 | 2008-01-27 |  | 17.74d |  |  |
| 3 | 1.2 | Obras preliminares |  | 1d | 2008-01-27 | 2008-01-28 |  | 16.74d |  |  |
| 4 | 1.3 | Movimiento de tierras |  | 2d | 2008-01-27 | 2008-01-29 |  | 15.74d |  |  |
| 5 | 1.4 | Obras de concreto |  | 6d | 2008-01-27 | 2008-02-02 |  | 0d |  |  |
| 6 | 1.5 | **SISTEMA RBS** |  | 6.85d | 2008-02-02 | 2008-02-08 |  | 0d |  |  |
| 7 | 1.5.1 | Estructuras metalicas |  | 3d | 2008-02-02 | 2008-02-05 | 11 | 0d |  |  |
| 8 | 1.5.2 | Muros RBS |  | 3d | 2008-02-03 | 2008-02-06 | 7SS+1d | 0d |  |  |
| 9 | 1.5.3 | Marco puerta RBS64 |  | 0.26d | 2008-02-06 | 2008-02-06 | 8 | 2.56d |  | start no earlier than 2008-02-04 |
| 10 | 1.5.4 | Contramarco Ventana RBS64 |  | 0.26d | 2008-02-06 | 2008-02-06 | 8 | 2.56d |  |  |
| 11 | 1.5.5 | Marco RBS64 para cimbrar muros |  | 0.24d | 2008-02-02 | 2008-02-02 | 5 | 0d |  |  |
| 12 | 1.5.6 | Techo RBS64 |  | 3.5d | 2008-02-05 | 2008-02-08 | 8SS+2d | 0d |  |  |
| 13 | 1.5.7 | Tapa de alero y timpano RBS64 |  | 0.11d | 2008-02-08 | 2008-02-08 | 12 | 0.21d |  |  |
| 14 | 1.5.8 | Tapa de pendiente RBS64 |  | 0.24d | 2008-02-06 | 2008-02-06 | 8 | 2.58d |  |  |
| 15 | 1.5.9 | Cumbrera |  | 0.06d | 2008-02-08 | 2008-02-08 | 12 | 4.68d | 0d |  |
| 16 | 1.5.10 | Teja RBS 64 |  | 1d | 2008-02-07 | 2008-02-08 | 12SS+2.5d | 0.32d |  |  |
| 17 | 1.6 | Cielo Raso |  | 2d | 2008-02-08 | 2008-02-10 | 12 | 3d |  |  |
| 18 | 1.7 | Sellos complementarios Sistema RBS |  | 2d | 2008-02-08 | 2008-02-10 | 12 | 3d |  |  |
| 19 | 1.8 | Ventanas |  | 1d | 2008-02-06 | 2008-02-07 | 10 | 6.24d |  |  |
| 20 | 1.9 | Puertas |  | 1d | 2008-02-06 | 2008-02-07 | 9 | 3.24d | 0d |  |
| 21 | 1.10 | Pisos y revestimiento |  | 5d | 2008-02-08 | 2008-02-13 | 12 | 0d |  |  |
| 22 | 1.11 | Aparatos sanitarios |  | 2d | 2008-02-07 | 2008-02-09 | 20 | 4.24d |  |  |
| 23 | 1.12 | Instalaciones sanitarias |  | 2d | 2008-01-31 | 2008-02-02 | 5SS+4d | 11.74d |  |  |
| 24 | 1.13 | Instalaciones Electricas |  | 2d | 2008-02-08 | 2008-02-10 | 12 | 3d |  |  |
