# cronograma 5.3.5 albañileria

Schedule from MS Project, 2008-01-27 to 2008-03-15.
MC

## Calendars

- Estándar: Mon-Sun 08:00-12:00, 13:00-17:00.

## Schedule

| ID | WBS | Task | Type | Duration | Start | Finish | Predecessors | Total slack |
| --- | --- | --- | --- | --- | --- | --- | --- | --- |
| 1 | 1 | **VIVIENDA ECONOMICA** |  | 48d | 2008-01-27 | 2008-03-15 |  | 0d |
| 2 | 1.1 | Inicio | milestone | 0d | 2008-01-27 | 2008-01-27 |  | 0d |
| 3 | 1.2 | Obras preliminares |  | 1d | 2008-01-27 | 2008-01-28 | 2SS | 0d |
| 4 | 1.3 | Movimiento de tierra |  | 2d | 2008-01-28 | 2008-01-30 | 3 | 0d |
| 5 | 1.4 | **ALBAÑILERIA** |  | 44d | 2008-01-30 | 2008-03-14 |  | 0d |
| 6 | 1.4.1 | Concreto simple |  | 3d | 2008-01-30 | 2008-02-02 | 4 | 0d |
| 7 | 1.4.2 | Falso piso |  | 2d | 2008-02-02 | 2008-02-04 | 6 | 0d |
| 8 | 1.4.3 | Concreto armado |  | 9d | 2008-02-04 | 2008-02-13 | 7 | 0d |
| 9 | 1.4.4 | Muros y tabiques de albañileria |  | 10d | 2008-02-13 | 2008-02-23 | 8 | 0d |
| 10 | 1.4.5 | Revoques y enlucidos |  | 9d | 2008-02-23 | 2008-03-03 | 9 | 0d |
| 11 | 1.4.6 | Cieloraso |  | 10d | 2008-02-23 | 2008-03-04 | 10SS | 0d |
| 12 | 1.4.7 | Pisos |  | 8d | 2008-03-04 | 2008-03-12 | 11 | 0d |
| 13 | 1.4.8 | Contrazocalo |  | 2d | 2008-03-12 | 2008-03-14 | 12 | 1d |
| 14 | 1.4.9 | Cobertura de ladrillo pastelero |  | 2d | 2008-03-04 | 2008-03-06 | 11 | 9d |
| 15 | 1.5 | Puertas |  | 1d | 2008-03-12 | 2008-03-13 | 12 | 0d |
| 16 | 1.6 | Ventana |  | 1d | 2008-03-12 | 2008-03-13 | 15SS | 2d |
| 17 | 1.7 | Pintura |  | 6d | 2008-03-04 | 2008-03-10 | 11 | 5d |
| 18 | 1.8 | Aparatos sanitarios |  | 2d | 2008-03-13 | 2008-03-15 | 15 | 0d |
| 19 | 1.9 | Instalacion sanitaria |  | 2d | 2008-01-31 | 2008-02-02 | 6SS+1d | 42d |
| 20 | 1.10 | Instalacion electrica |  | 2d | 2008-02-23 | 2008-02-25 | 9 | 19d |
